# Dr. Schmidt und Partner

Schedule from MS Project, 2012-10-01 to 2012-11-13, costs in €.
Project 2010_Übung 1
ACME Europe

## Calendars

- Standard: Mon-Fri 08:00-12:00, 13:00-17:00; Sat-Sun off.

## Resources

| Resource | Rate | Cost per use |
| --- | --- | --- |
| Peter | 90 | 50 |
| Paul | 70 |  |
| Mary | 80 |  |

## Schedule

| ID | WBS | Task | Type | Duration | Start | Finish | Predecessors | Total slack | Free slack | Resources | Work | Cost |
| --- | --- | --- | --- | --- | --- | --- | --- | --- | --- | --- | --- | --- |
| 1 | 1 | Erteilung des Auftrags | milestone | 0d | 2012-10-01 | 2012-10-01 |  | 0d |  |  |  |  |
| 2 | 2 | **Vorbereitungen** |  | 13d | 2012-10-01 | 2012-10-17 |  | 0d |  |  | 120h | 9,090 |
| 3 | 2.1 | Bestellung Hardware |  | 1d | 2012-10-01 | 2012-10-01 | 1 | 0d |  | Mary | 8h | 640 |
| 4 | 2.2 | Lieferung Hardware | milestone | 0d | 2012-10-08 | 2012-10-08 | 3FS+5d | 0d |  |  |  |  |
| 5 | 2.3 | Besprechung Kanzleiorganisation |  | 1d | 2012-10-02 | 2012-10-02 | 1 | 1d | 0d | Mary | 8h | 640 |
| 6 | 2.4 | Dokumentvorlagen erstellen |  | 3d | 2012-10-03 | 2012-10-05 | 5 | 1d |  | Paul | 24h | 1,680 |
| 7 | 2.5 | Systeme installieren |  | 3d | 2012-10-09 | 2012-10-11 | 4, 6 | 0d |  | Paul; Peter | 48h | 3,890 |
| 8 | 2.6 | Alte Stammdaten übernehmen |  | 4d | 2012-10-12 | 2012-10-17 | 7 | 0d |  | Paul | 32h | 2,240 |
| 9 | 3 | **Vor Ort** |  | 17d | 2012-10-01 | 2012-10-23 |  | 0d |  |  |  |  |
| 10 | 3.1 | Verkabelung |  | 5d | 2012-10-01 | 2012-10-05 | 1 | 8d |  |  |  |  |
| 11 | 3.2 | Auslieferung und Aufbau |  | 4d | 2012-10-18 | 2012-10-23 | 8, 10 | 0d |  |  |  |  |
| 12 | 4 | **Schulungen** |  | 16d | 2012-10-19 | 2012-11-09 |  | 0d |  |  |  |  |
| 13 | 4.1 | Schulung Word 1. Gruppe |  | 3d | 2012-10-19 | 2012-10-23 | 11FF | 0d |  |  |  |  |
| 14 | 4.2 | Schulung Word 2. Gruppe |  | 3d | 2012-10-24 | 2012-10-26 | 13 | 0d |  |  |  |  |
| 15 | 4.3 | Schulung Stammdaten 1. Gruppe |  | 2d | 2012-10-31 | 2012-11-01 | 13FS+1w, 14 | 1d |  |  |  |  |
| 16 | 4.4 | Schulung Stammdaten 2. Gruppe |  | 2d | 2012-11-05 | 2012-11-06 | 14FS+1w, 15 | 0d |  |  |  |  |
| 17 | 4.5 | Schulung Notariat |  | 1d | 2012-11-09 | 2012-11-09 | 18 | 2d |  |  |  |  |
| 18 | 4.6 | Schulung Buchhaltung |  | 2d | 2012-11-07 | 2012-11-08 | 16 | 0d |  |  |  |  |
| 19 | 5 | Zwischenrechnung | milestone | 0d | 2012-11-09 | 2012-11-09 | 12 | 2d |  |  |  |  |
| 20 | 6 | **Abschlussarbeiten** |  | 3d | 2012-11-09 | 2012-11-13 |  | 0d |  |  |  |  |
| 21 | 6.1 | Übernahme Buchhaltung |  | 2d | 2012-11-09 | 2012-11-12 | 18 | 0d |  |  |  |  |
| 22 | 6.2 | Abschalten/Entsorgen |  | 1d | 2012-11-13 | 2012-11-13 | 21 | 0d |  |  |  |  |
| 23 | 7 | Endrechnung | milestone | 0d | 2012-11-13 | 2012-11-13 | 22 | 0d |  |  |  |  |
