# Vorbereitung des Jahresberichts

Schedule from MS Project, 2007-01-01 to 2007-02-28.
In dieser Vorlage werden die allgemeinen Aktivitäten im Bereich Finanz- und Buchhaltungssystem erläutert, die in der Regel bei der Vorbereitung des Jahresfinanzberichts eingeschlossen sind. Die Vorlage schließt Aktivitäten zum Zusammenstellen der erforderlichen Informationen aus zahlreichen Abteilungen sowie zur Zusammenarbeit mit anderen Abteilungen ein (z. B. Rechtsabteilung und Public Relations). Auf diese Weise soll sichergestellt werden, dass alle erforderlichen Informationen ordnungsgemäß dargestellt werden. Ebenfalls eingeschlossen sind der Druck- sowie der Verteilungsprozess.

## Calendars

- Standard: Mon-Fri 08:00-12:00, 13:00-17:00; Sat-Sun off.

## Resources

| Resource |
| --- |
| Prüfungsausschuss |
| Rechtsabteilung |
| Externer Wirtschaftsprüfer |
| Exekutivkomitee |
| Leiter der Finanzabteilung oder Revisor |
| Marketinggruppe |
| Komitee für strategische Planung |
| PR/IR-Abteilung |
| Vorsitzender |

## Schedule

| ID | WBS | Task | Type | Duration | Start | Finish | Predecessors | Total slack | Free slack | Resources | Work |
| --- | --- | --- | --- | --- | --- | --- | --- | --- | --- | --- | --- |
| 1 | 1 | **Ausführen der Anfangsplanung** |  | 6d? | 2007-01-01 | 2007-01-08 |  | 0d |  |  | 48h |
| 2 | 1.1 | Überprüfen von Projektdatei/Erfahrungsberichten des Prozesses zum Jahresbericht des letzten Jahres |  | 1d? | 2007-01-01 | 2007-01-01 |  | 0d |  | Komitee für strategische Planung | 8h |
| 3 | 1.2 | Bestätigen der Änderungen an Anforderungen zur Vorlage des Finanzstatus (falls vorhanden) |  | 1d? | 2007-01-02 | 2007-01-02 | 2 | 0d |  | Leiter der Finanzabteilung oder Revisor | 8h |
| 4 | 1.3 | Ermitteln der Anforderungen an Design und Einteilung des Jahresberichts |  | 1d? | 2007-01-03 | 2007-01-03 | 3 | 0d |  | Komitee für strategische Planung | 8h |
| 5 | 1.4 | Bestätigen anderer Abschnitte, die hinzugefügt oder entfernt werden sollen |  | 1d? | 2007-01-04 | 2007-01-04 | 4 | 0d |  | Komitee für strategische Planung | 8h |
| 6 | 1.5 | Bestätigen von Prüfpunkten für die SEC-Einreichung und den Jahresbericht |  | 1d? | 2007-01-05 | 2007-01-05 | 5 | 0d |  | Leiter der Finanzabteilung oder Revisor | 8h |
| 7 | 1.6 | Auswahl interner Buchprüfer |  | 1d? | 2007-01-08 | 2007-01-08 | 6 | 0d |  | Prüfungsausschuss | 8h |
| 8 | 1.7 | Die Anfangsplanung ist abgeschlossen | milestone | 0d | 2007-01-08 | 2007-01-08 | 7 | 0d |  |  |  |
| 9 | 2 | **Entwerfen des Jahresberichts** |  | 6d? | 2007-01-09 | 2007-01-16 |  | 0d |  |  | 48h |
| 10 | 2.1 | Zuordnen von Ressourcen für den vorläufigen Entwurf |  | 1d? | 2007-01-09 | 2007-01-09 | 8 | 0d |  | Komitee für strategische Planung | 8h |
| 11 | 2.2 | Entwickeln des vorläufigen Entwurfs und des Informationsbedarfs |  | 1d? | 2007-01-10 | 2007-01-10 | 10 | 0d |  | Komitee für strategische Planung | 8h |
| 12 | 2.3 | **Auswerten/Bestätigen der Mechanismen zur Berichtsverteilung** |  | 3d? | 2007-01-11 | 2007-01-15 |  | 0d |  |  | 24h |
| 13 | 2.3.1 | Auswerten/Bestätigen der Vertragspartner für den Entwurf des Jahresberichts und für Kommunikationstechnik |  | 1d? | 2007-01-11 | 2007-01-11 | 11 | 0d |  | PR/IR-Abteilung | 8h |
| 14 | 2.3.2 | Auswerten/Bestätigen des Entwurfs der Unternehmenswebsite und der Integrationsanforderungen |  | 1d? | 2007-01-12 | 2007-01-12 | 13 | 0d |  | PR/IR-Abteilung | 8h |
| 15 | 2.3.3 | Auswerten/Bestätigen der Vertragspartner für die Erstellung des Jahresberichts und für dessen Versand |  | 1d? | 2007-01-15 | 2007-01-15 | 14 | 0d |  | PR/IR-Abteilung | 8h |
| 16 | 2.3.4 | Mechanismen für die Berichtsverteilung wurden bestätigt | milestone | 0d | 2007-01-15 | 2007-01-15 | 15 | 0d |  | PR/IR-Abteilung |  |
| 17 | 2.4 | Planen/Bestätigen des Erstellungszeitplans |  | 1d? | 2007-01-16 | 2007-01-16 | 16 | 0d |  | PR/IR-Abteilung | 8h |
| 18 | 2.5 | Der Entwurf des Jahresberichts ist abgeschlossen | milestone | 0d | 2007-01-16 | 2007-01-16 | 17 | 0d |  |  |  |
| 19 | 3 | **Definieren von Zeitplänen für die Erstellung von SEC 10-K und Stimmrechtsunterlagen** |  | 3d? | 2007-01-17 | 2007-01-19 |  | 0d |  |  | 24h |
| 20 | 3.1 | Planen/Bestätigen des 10-K-Erstellungszeitplans |  | 1d? | 2007-01-17 | 2007-01-17 | 18 | 0d |  | Leiter der Finanzabteilung oder Revisor | 8h |
| 21 | 3.2 | Planen/Bestätigen des Erstellungszeitplans für die Stimmrechtsvollmacht |  | 1d? | 2007-01-18 | 2007-01-18 | 20 | 0d |  | Leiter der Finanzabteilung oder Revisor | 8h |
| 22 | 3.3 | Ermitteln der für die Einhaltung des Erstellungszeitplans erforderlichen Prozessschritte |  | 1d? | 2007-01-19 | 2007-01-19 | 21 | 0d |  | Leiter der Finanzabteilung oder Revisor | 8h |
| 23 | 3.4 | Erstellungszeitpläne für SEC 10-K und Stimmrechtsunterlagen sind abgeschlossen | milestone | 0d | 2007-01-19 | 2007-01-19 | 22 | 0d |  |  |  |
| 24 | 4 | **Entwickeln des Jahresberichts** |  | 22d? | 2007-01-22 | 2007-02-20 |  | 5.5d |  |  | 216h |
| 25 | 4.1 | **Entwickeln der Erstellungskomponenten für das Design** |  | 7d? | 2007-01-22 | 2007-01-30 |  | 16.5d |  |  | 56h |
| 26 | 4.1.1 | Planen und Durchführen von Sitzungen zur Designentwicklung |  | 1d? | 2007-01-22 | 2007-01-22 | 23 | 16.5d | 0d | PR/IR-Abteilung | 8h |
| 27 | 4.1.2 | Sammeln von Nachrichten zur Designstatistik oder Designüberprüfung |  | 1d? | 2007-01-23 | 2007-01-23 | 26 | 16.5d | 0d | PR/IR-Abteilung | 8h |
| 28 | 4.1.3 | Befragen anderweitig am Design Beteiligter |  | 1d? | 2007-01-24 | 2007-01-24 | 27 | 16.5d | 0d | PR/IR-Abteilung | 8h |
| 29 | 4.1.4 | Entwickeln von Aufwertungen des ersten Designabschnitts |  | 1d? | 2007-01-25 | 2007-01-25 | 28 | 16.5d | 0d | PR/IR-Abteilung | 8h |
| 30 | 4.1.5 | Planen von Sitzungen für Designfoto und Websiteentwurf |  | 1d? | 2007-01-26 | 2007-01-26 | 29 | 16.5d | 0d | PR/IR-Abteilung | 8h |
| 31 | 4.1.6 | Überprüfen von Designfakten |  | 1d? | 2007-01-29 | 2007-01-29 | 30 | 16.5d | 0d | PR/IR-Abteilung | 8h |
| 32 | 4.1.7 | Abschließen von Designentwurf und Aufwertungen mit Führungskräften |  | 1d? | 2007-01-30 | 2007-01-30 | 31 | 16.5d | 0d | PR/IR-Abteilung | 8h |
| 33 | 4.1.8 | Die Designerstellung ist abgeschlossen | milestone | 0d | 2007-01-30 | 2007-01-30 | 32 | 16.5d | 0d |  |  |

Notes:
- 4: Nach dem Identifizieren des Designs entwickeln Sie eine Liste der anderweitig am Inhalt des Designs Beteiligten

| ID | WBS | Task | Type | Duration | Start | Finish | Predecessors | Total slack | Free slack | Resources | Work |
| --- | --- | --- | --- | --- | --- | --- | --- | --- | --- | --- | --- |
| 34 | 4.2 | **Entwickeln eines Briefes an die Aktionäre** |  | 15d? | 2007-01-31 | 2007-02-20 |  | 5.5d |  |  | 40h |
| 35 | 4.2.1 | Planen einer Befragung des Vorsitzenden oder des Geschäftsführers |  | 1d? | 2007-01-31 | 2007-01-31 | 33 | 16.5d | 0d | PR/IR-Abteilung | 8h |
| 36 | 4.2.2 | Durchführen der Befragung |  | 1d? | 2007-02-01 | 2007-02-01 | 35 | 16.5d | 0d | PR/IR-Abteilung; Vorsitzender | 16h |
| 37 | 4.2.3 | Erstellen und Überprüfen des Briefs |  | 1d? | 2007-02-02 | 2007-02-02 | 36 | 16.5d | 11d | PR/IR-Abteilung | 8h |
| 38 | 4.2.4 | Überprüfen des Briefs im Kontext des geprüften Finanzergebnisses |  | 1d? | 2007-02-20 | 2007-02-20 | 37, 83 | 5.5d | 0d | PR/IR-Abteilung | 8h |
| 39 | 4.2.5 | Der Brief an die Aktionäre ist abgeschlossen | milestone | 0d | 2007-02-20 | 2007-02-20 | 38 | 5.5d |  |  |  |
| 40 | 4.3 | **Definieren der auf Public Relations und Investor Relations fokussierten Komponenten** |  | 10.5d? | 2007-02-06 | 2007-02-20 |  | 0d |  |  | 120h |
| 41 | 4.3.1 | **Festlegen von PR- und IR-Meilensteinen** |  | 0.5d? | 2007-02-06 | 2007-02-06 |  | 0d |  |  | 4h |
| 42 | 4.3.1.1 | Definieren wichtiger PR- und IR-Meilensteine (Ausrichtung am Lieferumfang) |  | 0.5d? | 2007-02-06 | 2007-02-06 | 76 | 0d |  | PR/IR-Abteilung | 4h |
| 43 | 4.3.2 | **Entwickeln von Public Relations-Messaging** |  | 3.5d? | 2007-02-06 | 2007-02-09 |  | 11d |  |  | 28h |
| 44 | 4.3.2.1 | Definieren von PR-Messaging zum Einschließen in den Jahresbericht |  | 0.5d? | 2007-02-06 | 2007-02-06 | 42 | 11d | 0d | PR/IR-Abteilung | 4h |
| 45 | 4.3.2.2 | Definieren von PR-Messaging zum Finanzergebnis |  | 2d? | 2007-02-07 | 2007-02-08 | 44 | 11d | 0d | PR/IR-Abteilung | 16h |
| 46 | 4.3.2.3 | Optimieren der Verteilungskanäle und der Zeitvorgaben |  | 1d? | 2007-02-09 | 2007-02-09 | 45 | 11d | 6d | PR/IR-Abteilung | 8h |
| 47 | 4.3.3 | **Entwickeln von Investor Relations-Messaging** |  | 10d? | 2007-02-06 | 2007-02-20 |  | 0d |  |  | 88h |
| 48 | 4.3.3.1 | Definieren von IR-Messaging für den Jahresbericht |  | 2d? | 2007-02-06 | 2007-02-08 | 42 | 9.5d | 0d | PR/IR-Abteilung | 16h |
| 49 | 4.3.3.2 | Definieren von IR-Messaging zum Finanzergebnis |  | 2d? | 2007-02-08 | 2007-02-12 | 48 | 9.5d | 0d | PR/IR-Abteilung | 16h |
| 50 | 4.3.3.3 | Bestätigen der Verteilungslisten und -kanäle für die Erstellung des Jahresberichts |  | 2d? | 2007-02-12 | 2007-02-14 | 49 | 9.5d | 3.5d | PR/IR-Abteilung | 16h |
| 51 | 4.3.3.4 | Einholen des Finanzergebnisses vom Leiter der Finanzabteilung |  | 0.5d? | 2007-02-20 | 2007-02-20 | 50, 83 | 6d |  | Leiter der Finanzabteilung oder Revisor; PR/IR-Abteilung | 8h |
| 52 | 4.3.3.5 | **Bestätigen der Beschaffung von Adressenlisten und des Verteilungsprozesses für Aktionäre** |  | 4d? | 2007-02-06 | 2007-02-12 |  | 0d |  |  | 32h |
| 53 | 4.3.3.5.1 | Bestätigen der institutionellen Verteilungsliste oder des institutionellen Verteilungsprozesses |  | 1d? | 2007-02-06 | 2007-02-07 | 42 | 0d |  | PR/IR-Abteilung | 8h |
| 54 | 4.3.3.5.2 | Bestätigen der Maklerverteilungsliste oder des Maklerverteilungsprozesses |  | 1d? | 2007-02-07 | 2007-02-08 | 53 | 0d |  | PR/IR-Abteilung | 8h |
| 55 | 4.3.3.5.3 | Bestätigen der Verteilungsliste oder des Verteilungsprozesses für einzelne Investoren |  | 1d? | 2007-02-08 | 2007-02-09 | 54 | 0d |  | PR/IR-Abteilung | 8h |
| 56 | 4.3.3.5.4 | Bestätigen des Prozesses zum Aktualisieren, Formatieren oder Bereitstellen der Unternehmenswebsite |  | 1d? | 2007-02-09 | 2007-02-12 | 55 | 0d |  | PR/IR-Abteilung | 8h |
| 57 | 4.3.3.5.5 | Die Bestätigung des Bereitstellungs- & Verteilungsprozesses ist abgeschlossen | milestone | 0d | 2007-02-12 | 2007-02-12 | 56 | 0d |  |  |  |
| 58 | 4.3.4 | Die Entwicklung & Planung von PR- und IR-Messaging ist abgeschlossen | milestone | 0d | 2007-02-12 | 2007-02-12 | 57 | 0d |  |  |  |

| ID | WBS | Task | Type | Duration | Start | Finish | Predecessors | Total slack | Free slack | Resources | Work |
| --- | --- | --- | --- | --- | --- | --- | --- | --- | --- | --- | --- |
| 59 | 5 | **Ausführen von Aktivitäten zum Hauptabschluss** |  | 22.5d? | 2007-01-22 | 2007-02-21 |  | 0d |  |  | 196h |
| 60 | 5.1 | **Definieren von Komponenten der Finanzprüfung und des Zeitplans für das entsprechende SEC-Dokument** |  | 5d? | 2007-01-22 | 2007-01-26 |  | 0d |  |  | 48h |
| 61 | 5.1.1 | Entwickeln des Zeitplans für den Hauptabschluss |  | 1d? | 2007-01-22 | 2007-01-22 | 23 | 0d |  | Leiter der Finanzabteilung oder Revisor | 8h |
| 62 | 5.1.2 | Entwickeln und Bestätigen des Zeitplans für die Betriebsprüfung |  | 1d? | 2007-01-23 | 2007-01-23 | 61 | 0d |  | Externer Wirtschaftsprüfer; Leiter der Finanzabteilung oder Revisor | 16h |
| 63 | 5.1.3 | Bestimmen oder Zuweisen von Ressourcen zum Entwickeln und Bestätigen von Bilanzen und Anmerkungen |  | 1d? | 2007-01-24 | 2007-01-24 | 62 | 0d |  | Leiter der Finanzabteilung oder Revisor | 8h |
| 64 | 5.1.4 | Bestimmen oder Zuweisen von Ressourcen zum Entwickeln und Bestätigen des 10-K-Abschnitts |  | 1d? | 2007-01-25 | 2007-01-25 | 63 | 0d |  | Leiter der Finanzabteilung oder Revisor | 8h |
| 65 | 5.1.5 | Bestimmen oder Zuweisen von Ressourcen zum Entwickeln und Bestätigen des Abschnitts mit der Stimmrechtsvollmacht |  | 1d? | 2007-01-26 | 2007-01-26 | 64 | 0d |  | Leiter der Finanzabteilung oder Revisor | 8h |
| 66 | 5.1.6 | Die Finanzprüfung und Erstellung des Zeitplans für das entsprechende SEC-Dokument sind abgeschlossen | milestone | 0d | 2007-01-26 | 2007-01-26 | 65 | 0d |  |  |  |
| 67 | 5.2 | **Ausführen des Hauptabschlusses** |  | 3d? | 2007-01-29 | 2007-01-31 |  | 0d |  |  | 24h |
| 68 | 5.2.1 | Abschießen der Bücher für das Geschäftsjahr |  | 1d? | 2007-01-29 | 2007-01-29 | 66 | 0d |  | Leiter der Finanzabteilung oder Revisor | 8h |
| 69 | 5.2.2 | Ausführen der Prüfung und Genehmigung von Bilanzanpassungen (Fälligkeiten und Rücklagen) |  | 1d? | 2007-01-30 | 2007-01-30 | 68 | 0d |  | Leiter der Finanzabteilung oder Revisor | 8h |
| 70 | 5.2.3 | Entwickeln des Finanzergebnisses zum Einschließen in den Jahresbericht, in 10-K und in die Stimmrechtsvollmacht |  | 1d? | 2007-01-31 | 2007-01-31 | 69 | 0d |  | Leiter der Finanzabteilung oder Revisor | 8h |
| 71 | 5.2.4 | Der Hauptabschluss und das Finanzergebnis sind abgeschlossen | milestone | 0d | 2007-01-31 | 2007-01-31 | 70 | 0d |  |  |  |
| 72 | 5.3 | **Entwickeln von Bilanzanmerkungen und SEC-Dokumenten** |  | 3d? | 2007-02-01 | 2007-02-05 |  | 0d |  |  | 24h |
| 73 | 5.3.1 | Entwerfen von Bilanzanmerkungen |  | 1d? | 2007-02-01 | 2007-02-01 | 71 | 0d |  | Leiter der Finanzabteilung oder Revisor | 8h |
| 74 | 5.3.2 | Entwerfen des 10-K |  | 1d? | 2007-02-02 | 2007-02-02 | 73 | 0d |  | Leiter der Finanzabteilung oder Revisor | 8h |
| 75 | 5.3.3 | Entwerfen von Informationen zur Stimmrechtsvollmacht |  | 1d? | 2007-02-05 | 2007-02-05 | 74 | 0d |  | Rechtsabteilung | 8h |
| 76 | 5.3.4 | Entwürfe von Bilanzanmerkungen und SEC-Dokumenten sind abgeschlossen | milestone | 0d | 2007-02-05 | 2007-02-05 | 75 | 0d |  |  |  |
| 77 | 5.4 | **Ausführen der Betriebsprüfung** |  | 4d? | 2007-02-14 | 2007-02-19 |  | 5d |  |  | 44h |
| 78 | 5.4.1 | Ausführen der Abschlussprüfung in Niederlassungen im In- und Ausland |  | 1d? | 2007-02-14 | 2007-02-14 | 91 | 5d | 0d | Externer Wirtschaftsprüfer | 8h |
| 79 | 5.4.2 | Ausführen der Abschlussprüfung im Unternehmen |  | 1d? | 2007-02-15 | 2007-02-15 | 78 | 5d | 0d | Externer Wirtschaftsprüfer | 8h |
| 80 | 5.4.3 | Die Betriebsprüfung ist abgeschlossen | milestone | 0d | 2007-02-15 | 2007-02-15 | 79 | 5d | 0d |  |  |
| 81 | 5.4.4 | Überprüfen und Abschließen der Prüfungsergebnisse mit dem Prüfungsausschuss |  | 1d? | 2007-02-16 | 2007-02-16 | 80 | 5d | 0d | Prüfungsausschuss; Externer Wirtschaftsprüfer; Leiter der Finanzabteilung oder Revisor | 12h |
| 82 | 5.4.5 | Abschließen der Bilanzen oder Abnahme durch das Management |  | 1d? | 2007-02-19 | 2007-02-19 | 81 | 5d | 0d | Prüfungsausschuss; Leiter der Finanzabteilung oder Revisor | 16h |
| 83 | 5.4.6 | Die Betriebsprüfung ist abgeschlossen | milestone | 0d | 2007-02-19 | 2007-02-19 | 82 | 5d | 0d |  |  |

Notes:
- 61: Basieren Sie den Zeitplan auf den Zeit- und Ressourcenaufwand, der zum Erreichen von Meilensteinen zum Schließen der Bilanzbücher und zum Erstellen der für den Jahresbericht und 10-K erforderlichen Bilanzinformationen erforderlich ist. / In anderen Worten: Bestimmen Sie zunächst die Termine, und bestimmen Sie auf dieser Grundlage, wann Sie mit den Aktivitäten beginnen müssen, um diese Stichtage einzuhalten.
- 77: Aktivitäten der Betriebsprüfung werden das ganze Jahr hindurch ausgeführt. Diese Aktivitäten konzentrieren sich auf den Jahresabschluss und werden mit dem Erstellen des Jahresberichts und der Bilanzen beendet, die von den externen Wirtschaftsprüfern abgenommen werden.

| ID | WBS | Task | Type | Duration | Start | Finish | Predecessors | Total slack | Free slack | Resources | Work |
| --- | --- | --- | --- | --- | --- | --- | --- | --- | --- | --- | --- |
| 84 | 5.5 | **Ausführen einer internen juristischen Überprüfung** |  | 6d? | 2007-02-06 | 2007-02-13 |  | 5d |  |  | 48h |
| 85 | 5.5.1 | Koordinieren und Überprüfen wichtiger Ereignisse zum Einschließen in den Jahresbericht |  | 1d? | 2007-02-06 | 2007-02-06 | 76 | 5d | 0d | Rechtsabteilung | 8h |
| 86 | 5.5.2 | Koordinieren und Überprüfen wichtiger Ereignisse zum Einschließen in 10-K |  | 1d? | 2007-02-07 | 2007-02-07 | 85 | 5d | 0d | Rechtsabteilung | 8h |
| 87 | 5.5.3 | Koordinieren oder Planen der Entwicklung der Stimmrechtsvollmacht |  | 1d? | 2007-02-08 | 2007-02-08 | 86 | 5d | 0d | Rechtsabteilung | 8h |
| 88 | 5.5.4 | Koordinieren oder Überprüfen der Nachricht an die Aktionäre |  | 1d? | 2007-02-09 | 2007-02-09 | 87 | 5d | 0d | Rechtsabteilung | 8h |
| 89 | 5.5.5 | Koordinieren oder Überprüfen der Betriebsprüfung und der Kommentare |  | 1d? | 2007-02-12 | 2007-02-12 | 88 | 5d | 0d | Rechtsabteilung | 8h |
| 90 | 5.5.6 | Koordinieren oder Überprüfen der Abnahme durch das Management |  | 1d? | 2007-02-13 | 2007-02-13 | 89 | 5d | 0d | Rechtsabteilung | 8h |
| 91 | 5.5.7 | Die interne juristische Überprüfung ist abgeschlossen | milestone | 0d | 2007-02-13 | 2007-02-13 | 90 | 5d | 0d |  |  |
| 92 | 5.6 | Veröffentlichen des Finanzergebnisses |  | 0.5d? | 2007-02-20 | 2007-02-20 | 46, 83 | 5d | 0d | Prüfungsausschuss; Leiter der Finanzabteilung oder Revisor; PR/IR-Abteilung; Vorsitzender | 8h |
| 93 | 5.7 | Der Bilanzabschluss ist abgeschlossen |  | 1d? | 2007-02-20 | 2007-02-21 | 92 | 5d |  |  |  |
| 94 | 6 | **Erstellen des Jahresberichts** |  | 8d? | 2007-02-12 | 2007-02-22 |  | 0d |  |  | 64h |
| 95 | 6.1 | Entwerfen des Layouts für den Jahresbericht und Bestimmen von Platzhaltern |  | 1d? | 2007-02-12 | 2007-02-13 | 58 | 0d |  | PR/IR-Abteilung | 8h |
| 96 | 6.2 | Vorbereiten von Modellen für den Vorstand |  | 1d? | 2007-02-13 | 2007-02-14 | 95 | 0d |  | PR/IR-Abteilung | 8h |
| 97 | 6.3 | Wiederholen des Entwerfens oder Abschließens des Erstellungszeitplans |  | 1d? | 2007-02-14 | 2007-02-15 | 96 | 0d |  | PR/IR-Abteilung | 8h |
| 98 | 6.4 | Abschließen des Entwurfs des Jahresabschlusses und der Platzhalterdaten |  | 1d? | 2007-02-15 | 2007-02-16 | 97 | 0d |  | PR/IR-Abteilung | 8h |
| 99 | 6.5 | Erstellen des endgültigen Layouts oder Einholen der abschließenden Genehmigung |  | 1d? | 2007-02-16 | 2007-02-19 | 98 | 0d |  | PR/IR-Abteilung | 8h |
| 100 | 6.6 | Drucken des Jahresberichts |  | 1d? | 2007-02-19 | 2007-02-20 | 99 | 0d |  | PR/IR-Abteilung | 8h |
| 101 | 6.7 | Beschaffen der 10-K-Dokumentdatei |  | 1d? | 2007-02-20 | 2007-02-21 | 100 | 0d |  | PR/IR-Abteilung | 8h |
| 102 | 6.8 | Beschaffen der Dokumentdatei mit der Stimmrechtsvollmacht |  | 1d? | 2007-02-21 | 2007-02-22 | 101 | 0d |  | PR/IR-Abteilung | 8h |
| 103 | 6.9 | Die Erstellung des Jahresberichts ist abgeschlossen | milestone | 0d | 2007-02-22 | 2007-02-22 | 102 | 0d |  |  |  |
| 104 | 7 | **Verteilen des Jahresberichts** |  | 4d? | 2007-02-22 | 2007-02-28 |  | 0d |  |  | 32h |
| 105 | 7.1 | Beschaffen der endgültigen Adressenverteilerlisten |  | 1d? | 2007-02-22 | 2007-02-23 | 103 | 0d |  | PR/IR-Abteilung | 8h |
| 106 | 7.2 | Drucken des 10-K zum Versenden des Jahresberichts |  | 1d? | 2007-02-23 | 2007-02-26 | 105 | 0d |  | PR/IR-Abteilung | 8h |
| 107 | 7.3 | Drucken der Stimmrechtsvollmacht zum Versenden des Jahresberichts |  | 1d? | 2007-02-26 | 2007-02-27 | 106 | 0d |  | PR/IR-Abteilung | 8h |
| 108 | 7.4 | Zusammenführen und Versenden von Jahresberichten |  | 1d? | 2007-02-27 | 2007-02-28 | 107 | 0d |  | PR/IR-Abteilung | 8h |
| 109 | 7.5 | Die Verteilung ist abgeschlossen | milestone | 0d | 2007-02-28 | 2007-02-28 | 108 | 0d |  |  |  |
| 110 | 8 | Der Jahresbericht ist abgeschlossen | milestone | 0d | 2007-02-28 | 2007-02-28 | 109 | 0d |  |  |  |
