# Dr. Schmidt und Partner

Schedule from MS Project, 2012-10-01 to 2012-11-14, costs in €.
Project 2010_Übung 1
ACME Europe

## Calendars

- Standard: Mon-Fri 08:00-12:00, 13:00-17:00; Sat-Sun off.

## Resources

| Resource | Unit | Rate | Cost per use |
| --- | --- | --- | --- |
| Peter |  | 90 | 50 |
| Paul |  | 70 |  |
| Mary |  | 80 |  |
| Farbe, weiß | Liter | 2 |  |
| Fahrtkosten |  |  |  |

## Schedule

| ID | WBS | Task | Type | Duration | Start | Finish | Predecessors | Baseline start | Baseline finish | Baseline duration | Total slack | Free slack | Resources | Work | Cost | Baseline cost | Dauer ok? |
| --- | --- | --- | --- | --- | --- | --- | --- | --- | --- | --- | --- | --- | --- | --- | --- | --- | --- |
| 1 | 1 | Erteilung des Auftrags | milestone | 0d | 2012-10-01 | 2012-10-01 |  | 2012-10-01 | 2012-10-01 | 0d | 0d |  |  |  |  |  | Dauer ok. |
| 2 | 2 | **Vorbereitungen** |  | 14d | 2012-10-01 | 2012-10-18 |  | 2012-10-01 | 2012-10-17 | 13d | 0d |  |  | 128h | 9,810 | 9,170 |  |
| 3 | 2.1 | Bestellung Hardware |  | 2d | 2012-10-01 | 2012-10-02 | 1 | 2012-10-01 | 2012-10-01 | 1d | 0d |  | Mary | 16h | 1,330 | 690 | Dauer ok. |
| 4 | 2.2 | Lieferung Hardware | milestone | 0d | 2012-10-09 | 2012-10-09 | 3FS+5d | 2012-10-08 | 2012-10-08 | 0d | 0d |  |  |  |  |  | Dauer ok. |
| 5 | 2.3 | Besprechung Kanzleiorganisation |  | 1d | 2012-10-02 | 2012-10-02 | 1 | 2012-10-02 | 2012-10-02 | 1d | 2d | 0d | Mary | 8h | 640 | 640 | Dauer ok. |
| 6 | 2.4 | Dokumentvorlagen erstellen |  | 3d | 2012-10-03 | 2012-10-05 | 5 | 2012-10-03 | 2012-10-05 | 3d | 2d |  | Paul | 24h | 1,680 | 1,680 | Dauer ok. |
| 7 | 2.5 | Systeme installieren |  | 3d | 2012-10-10 | 2012-10-12 | 4, 6 | 2012-10-09 | 2012-10-11 | 3d | 0d |  | Paul; Peter; Fahrtkosten [0.1%] | 48h | 3,920 | 3,920 | Dauer ok. |
| 8 | 2.6 | Alte Stammdaten übernehmen |  | 4d | 2012-10-15 | 2012-10-18 | 7 | 2012-10-12 | 2012-10-17 | 4d | 0d |  | Paul | 32h | 2,240 | 2,240 | Dauer zu lang! |
| 9 | 3 | **Vor Ort** |  | 18d | 2012-10-01 | 2012-10-24 |  | 2012-10-01 | 2012-10-23 | 17d | 0d |  |  |  | 50 | 50 |  |
| 10 | 3.1 | Verkabelung |  | 5d | 2012-10-01 | 2012-10-05 | 1 | 2012-10-01 | 2012-10-05 | 5d | 9d |  |  |  |  |  | Dauer zu lang! |
| 11 | 3.2 | Auslieferung und Aufbau |  | 4d | 2012-10-19 | 2012-10-24 | 8, 10 | 2012-10-18 | 2012-10-23 | 4d | 0d |  | Fahrtkosten [0.1%] |  | 50 | 50 | Dauer zu lang! |
| 12 | 4 | **Schulungen** |  | 16d | 2012-10-22 | 2012-11-12 |  | 2012-10-19 | 2012-11-09 | 16d | 0d |  |  |  |  |  |  |
| 13 | 4.1 | Schulung Word 1. Gruppe |  | 3d | 2012-10-22 | 2012-10-24 | 11FF | 2012-10-19 | 2012-10-23 | 3d | 0d |  |  |  |  |  | Dauer ok. |
| 14 | 4.2 | Schulung Word 2. Gruppe |  | 3d | 2012-10-25 | 2012-10-29 | 13 | 2012-10-24 | 2012-10-26 | 3d | 0d |  |  |  |  |  | Dauer ok. |
| 15 | 4.3 | Schulung Stammdaten 1. Gruppe |  | 2d | 2012-11-01 | 2012-11-02 | 13FS+1w, 14 | 2012-10-31 | 2012-11-01 | 2d | 1d |  |  |  |  |  | Dauer ok. |
| 16 | 4.4 | Schulung Stammdaten 2. Gruppe |  | 2d | 2012-11-06 | 2012-11-07 | 14FS+1w, 15 | 2012-11-05 | 2012-11-06 | 2d | 0d |  |  |  |  |  | Dauer ok. |
| 17 | 4.5 | Schulung Notariat |  | 1d | 2012-11-12 | 2012-11-12 | 18 | 2012-11-09 | 2012-11-09 | 1d | 2d |  |  |  |  |  | Dauer ok. |
| 18 | 4.6 | Schulung Buchhaltung |  | 2d | 2012-11-08 | 2012-11-09 | 16 | 2012-11-07 | 2012-11-08 | 2d | 0d |  |  |  |  |  | Dauer ok. |
| 19 | 5 | Zwischenrechnung | milestone | 0d | 2012-11-12 | 2012-11-12 | 12 | 2012-11-09 | 2012-11-09 | 0d | 2d |  |  |  |  |  | Dauer ok. |
| 20 | 6 | **Abschlussarbeiten** |  | 3d | 2012-11-12 | 2012-11-14 |  | 2012-11-09 | 2012-11-13 | 3d | 0d |  |  |  |  |  |  |
| 21 | 6.1 | Übernahme Buchhaltung |  | 2d | 2012-11-12 | 2012-11-13 | 18 | 2012-11-09 | 2012-11-12 | 2d | 0d |  |  |  |  |  | Dauer ok. |
| 22 | 6.2 | Abschalten/Entsorgen |  | 1d | 2012-11-14 | 2012-11-14 | 21 | 2012-11-13 | 2012-11-13 | 1d | 0d |  |  |  |  |  | Dauer ok. |
| 23 | 7 | Endrechnung | milestone | 0d | 2012-11-14 | 2012-11-14 | 22 | 2012-11-13 | 2012-11-13 | 0d | 0d |  |  |  |  |  | Dauer ok. |
