# 3-Einfamilienhaus mit Pufferzeiten

Schedule from MS Project, 2007-01-01 to 2007-07-31.

## Calendars

- Standard: Mon-Fri 08:00-12:00, 13:00-17:00; Sat-Sun off.

## Resources

| Resource |
| --- |
| Betonbaufirma |
| Schreinerfirma |
| Zaunbaufirma |
| Maurerfirma |
| Bauträger |
| Architekt |
| Eigentümer |
| Kreditgeber |
| Bauordnungsamt |
| Stromversorgungsunternehmen |
| Tiefbaufirma |
| Elektroinstallationsfirma |
| Sanitärinstallationsfirma |
| Zimmereifirma |
| Dachdeckerfirma |
| Klimatechnikfirma |
| Isoliertechnikfirma |
| Trockenbaufirma |
| Malerfirma |
| Fußbodentechnikfirma |
| Haushaltsgerätelieferant |
| Gartenbaufirma |
| Reinigungsfirma |

## Schedule

| ID | WBS | Task | Type | Duration | Start | Finish | Predecessors | Total slack | Resources | Work |
| --- | --- | --- | --- | --- | --- | --- | --- | --- | --- | --- |
| 1 | 1 | **Einfamilienhaus - Architektenentwurf (Holzbalkenwerk, 110 Quadratmeter, voll unterkellert)** |  | 152d | 2007-01-01 | 2007-07-31 |  | 0d |  | 1584.53h |
| 2 | 1.1 | **Allgemeine Voraussetzungen** |  | 21d | 2007-01-01 | 2007-01-29 |  | 0d |  | 32.53h |
| 3 | 1.1.1 | Abschließen der Pläne und Erstellen eines Kostenvoranschlages mit Eigentümer, Architekt |  | 20d | 2007-01-01 | 2007-01-26 |  | 0d | Bauträger [50%]; Architekt [50%]; Eigentümer [12%]; Kreditgeber [12%] | 20.53h |
| 4 | 1.1.2 | Unterschreiben des Kreditvertrages und des Bauauftrages |  | 1d | 2007-01-29 | 2007-01-29 | 3 | 0d | Bauträger; Architekt; Eigentümer; Kreditgeber | 12h |
| 5 | 1.1.3 | **Einholen der Genehmigungen** |  | 0d | 2007-01-29 | 2007-01-29 |  | 0d |  |  |
| 6 | 1.1.3.1 | Genehmigung für das Fundament | milestone | 0d | 2007-01-29 | 2007-01-29 | 4 | 0d | Bauträger |  |
| 7 | 1.1.3.2 | Genehmigung für das Balkenwerk | milestone | 0d | 2007-01-29 | 2007-01-29 | 4 | 0d | Bauträger |  |
| 8 | 1.1.3.3 | Genehmigung für die Elektroinstallation | milestone | 0d | 2007-01-29 | 2007-01-29 | 4 | 0d | Bauträger |  |
| 9 | 1.1.3.4 | Genehmigung für die Sanitärinstallation | milestone | 0d | 2007-01-29 | 2007-01-29 | 4 | 0d | Bauträger |  |
| 10 | 1.1.3.5 | Genehmigung für die Klimaanlage | milestone | 0d | 2007-01-29 | 2007-01-29 | 4 | 0d | Bauträger |  |
| 11 | 1.1.3.6 | Verschiedene Genehmigungen | milestone | 0d | 2007-01-29 | 2007-01-29 | 4 | 0d | Bauträger |  |
| 12 | 1.2 | **Bauplatzarbeiten** |  | 3d | 2007-01-30 | 2007-02-01 |  | 0d |  | 32h |
| 13 | 1.2.1 | Säubern und Begradigen des Bauplatzes |  | 1d | 2007-01-30 | 2007-01-30 | 6, 7, 8, 9, 11, 10 | 0d | Tiefbaufirma | 8h |
| 14 | 1.2.2 | Installieren des provisorischen Stromanschlusses |  | 1d | 2007-01-31 | 2007-01-31 | 13 | 0d | Stromversorgungsunternehmen | 8h |
| 15 | 1.2.3 | Verlegen der Erdkabel und -leitungen |  | 1d | 2007-02-01 | 2007-02-01 | 14 | 0d | Elektroinstallationsfirma; Sanitärinstallationsfirma | 16h |
| 16 | 1.3 | **Fundament** |  | 42d | 2007-02-02 | 2007-04-02 |  | 0d |  | 280h |
| 17 | 1.3.1 | Ausschachtungsarbeiten für Fundament |  | 3d | 2007-02-02 | 2007-02-06 | 15 | 0d | Tiefbaufirma | 24h |
| 18 | 1.3.2 | Schalen der Kellerwände |  | 13d | 2007-02-07 | 2007-02-23 | 17 | 0d | Betonbaufirma | 104h |
| 19 | 1.3.3 | Gießen des Fundaments und der Kellerwände |  | 12d | 2007-02-26 | 2007-03-13 | 18 | 0d | Betonbaufirma | 96h |
| 20 | 1.3.4 | Trocknen der Kellerwände (7 Tage) |  | 7d | 2007-03-14 | 2007-03-22 | 19 | 0d |  |  |
| 21 | 1.3.5 | Ausschalen der Kellerwände |  | 2d | 2007-03-23 | 2007-03-26 | 20 | 0d | Betonbaufirma | 16h |
| 22 | 1.3.6 | Abdichten/Isolieren der Kellerwände |  | 2d | 2007-03-27 | 2007-03-28 | 21 | 0d | Betonbaufirma | 16h |
| 23 | 1.3.7 | Abnehmen des Fundamentes |  | 1d | 2007-03-29 | 2007-03-29 | 22, 17 | 0d | Bauordnungsamt | 8h |
| 24 | 1.3.8 | Anfüllen des Fundamentes |  | 2d | 2007-03-30 | 2007-04-02 | 23 | 0d | Tiefbaufirma | 16h |

| ID | WBS | Task | Duration | Start | Finish | Predecessors | Total slack | Free slack | Resources | Work |
| --- | --- | --- | --- | --- | --- | --- | --- | --- | --- | --- |
| 25 | 1.4 | **Balkenwerk** | 22d | 2007-04-03 | 2007-05-02 |  | 0d |  |  | 176h |
| 26 | 1.4.1 | Einziehen der Kellerdeckenbalken | 2d | 2007-04-03 | 2007-04-04 | 24 | 0d |  | Zimmereifirma | 16h |
| 27 | 1.4.2 | Legen der Erdgeschossdielen | 2d | 2007-04-05 | 2007-04-06 | 26 | 0d |  | Zimmereifirma | 16h |
| 28 | 1.4.3 | Zimmern der Erdgeschosswände | 4d | 2007-04-09 | 2007-04-12 | 27 | 0d |  | Zimmereifirma | 32h |
| 29 | 1.4.4 | Zimmern der Erdgeschossecken | 1d | 2007-04-13 | 2007-04-13 | 28 | 0d |  | Zimmereifirma | 8h |
| 30 | 1.4.5 | Einziehen der Erdgeschossdeckenbalken | 2d | 2007-04-16 | 2007-04-17 | 29 | 0d |  | Zimmereifirma | 16h |
| 31 | 1.4.6 | Legen der Dielen des 1. Geschosses | 2d | 2007-04-18 | 2007-04-19 | 30 | 0d |  | Zimmereifirma | 16h |
| 32 | 1.4.7 | Zimmern der Wände des 1. Geschosses | 3d | 2007-04-20 | 2007-04-24 | 31 | 0d |  | Zimmereifirma | 24h |
| 33 | 1.4.8 | Zimmern der Ecken des 1. Geschosses | 2d | 2007-04-25 | 2007-04-26 | 32 | 0d |  | Zimmereifirma | 16h |
| 34 | 1.4.9 | Zimmern des Dachstuhles | 3d | 2007-04-27 | 2007-05-01 | 33 | 0d |  | Zimmereifirma | 24h |
| 35 | 1.4.10 | Abnehmen der Balkenwerks | 1d | 2007-05-02 | 2007-05-02 | 34 | 0d |  | Bauordnungsamt | 8h |
| 36 | 1.5 | **Wetterfest machen** | 22d | 2007-05-02 | 2007-05-31 |  | 0d |  |  | 152h |
| 37 | 1.5.1 | Anbringen der Erdgeschossverkleidung | 3d | 2007-05-03 | 2007-05-07 | 35 | 0d |  | Zimmereifirma | 24h |
| 38 | 1.5.2 | Anbringen der Verkleidung des 1. Geschosses | 3d | 2007-05-08 | 2007-05-10 | 37 | 0d |  | Zimmereifirma | 24h |
| 39 | 1.5.3 | Legen der Dachdielen | 3d | 2007-05-02 | 2007-05-04 | 34 | 4d | 0d | Zimmereifirma | 24h |
| 40 | 1.5.4 | Aufbringen der Unterspannbahn, der Traufbleche und der Dachpfannen | 3d | 2007-05-18 | 2007-05-22 | 48 | 0d |  | Dachdeckerfirma | 24h |
| 41 | 1.5.5 | Einhängen der Außentüren des Erdgeschosses | 1d | 2007-05-23 | 2007-05-23 | 40 | 0d |  | Zimmereifirma | 8h |
| 42 | 1.5.6 | Einbauen der Erdgeschossfenster | 3d | 2007-05-24 | 2007-05-28 | 41 | 0d |  | Zimmereifirma | 24h |
| 43 | 1.5.7 | Einbauen der Fenster des 1. Geschosses | 3d | 2007-05-29 | 2007-05-31 | 42 | 0d |  | Zimmereifirma | 24h |
| 44 | 1.6 | **Fassade** | 19d | 2007-06-01 | 2007-06-27 |  | 5d |  |  | 152h |
| 45 | 1.6.1 | Ausmauern der Außenwände | 16d | 2007-06-01 | 2007-06-22 | 43 | 5d | 0d | Maurerfirma | 128h |
| 46 | 1.6.2 | Vervollständigen der Fassadenverkleidung | 3d | 2007-06-25 | 2007-06-27 | 45 | 5d | 0d | Zimmereifirma | 24h |
| 47 | 1.7 | **Leitungen/Rohre verlegen und Betonarbeiten abschließen** | 21d | 2007-05-07 | 2007-06-04 |  | 4d |  |  | 232h |
| 48 | 1.7.1 | Verlegen der Sanitärleitungen | 5d | 2007-05-11 | 2007-05-17 | 39, 38 | 0d |  | Sanitärinstallationsfirma | 40h |
| 49 | 1.7.2 | Abnehmen der Sanitärleitungen | 1d | 2007-05-18 | 2007-05-18 | 48 | 20d | 0d | Bauordnungsamt | 8h |
| 50 | 1.7.3 | Gießen des Kellerfußbodens | 11d | 2007-05-21 | 2007-06-04 | 49 | 33d |  | Betonbaufirma | 88h |
| 51 | 1.7.4 | Verlegen der Elektroleitungen | 5d | 2007-05-11 | 2007-05-17 | 39, 38 | 6d | 0d | Elektroinstallationsfirma | 40h |
| 52 | 1.7.5 | Abnehmen der Elektroleitungen | 1d | 2007-05-18 | 2007-05-18 | 51 | 6d | 0d | Bauordnungsamt | 8h |
| 53 | 1.7.6 | Verlegen der Klimaanlagenrohre | 3d | 2007-05-21 | 2007-05-23 | 52 | 6d | 0d | Klimatechnikfirma | 24h |
| 54 | 1.7.7 | Abnehmen der Klimaanlagenrohre | 1d | 2007-05-24 | 2007-05-24 | 53 | 24d |  | Bauordnungsamt | 8h |
| 55 | 1.7.8 | Verlegen der Kommunikationsleitungen: Telefon, Kabelanschluss, Computer, Alarmanlage | 2d | 2007-05-07 | 2007-05-08 | 39 | 17d |  | Elektroinstallationsfirma | 16h |

| ID | WBS | Task | Duration | Start | Finish | Predecessors | Total slack | Free slack | Resources | Work |
| --- | --- | --- | --- | --- | --- | --- | --- | --- | --- | --- |
| 56 | 1.8 | **Innenausbau** | 30d | 2007-06-01 | 2007-07-12 |  | 0d |  |  | 408h |
| 57 | 1.8.1 | **Isolierung** | 11d | 2007-06-01 | 2007-06-15 |  | 0d |  |  | 32h |
| 58 | 1.8.1.1 | Anbringen der Wandisolierung, Erdgeschoss | 1d | 2007-06-01 | 2007-06-01 | 37, 43, 55, 53, 51, 38 | 0d |  | Isoliertechnikfirma | 8h |
| 59 | 1.8.1.2 | Anbringen der Wandisolierung, 1. Geschoss | 1d | 2007-06-04 | 2007-06-04 | 58 | 27d | 3d | Isoliertechnikfirma | 8h |
| 60 | 1.8.1.3 | Anbringen der Deckenisolierung, 1. Geschoss | 1d | 2007-06-14 | 2007-06-14 | 66, 59 | 24d | 0d | Isoliertechnikfirma | 8h |
| 61 | 1.8.1.4 | Abnehmen der Isolierung | 1d | 2007-06-15 | 2007-06-15 | 60 | 24d |  | Bauordnungsamt | 8h |
| 62 | 1.8.2 | **Trockenausbau** | 9d | 2007-06-04 | 2007-06-14 |  | 0d |  |  | 80h |
| 63 | 1.8.2.1 | Ausführen Trockenausbau - Erdgeschosswände | 2d | 2007-06-04 | 2007-06-05 | 58 | 0d |  | Trockenbaufirma | 16h |
| 64 | 1.8.2.2 | Ausführen Trockenausbau - Erdgeschossdecke | 2d | 2007-06-06 | 2007-06-07 | 63 | 0d |  | Trockenbaufirma | 16h |
| 65 | 1.8.2.3 | Ausführen Trockenausbau - Wände des 1. Geschosses | 2d | 2007-06-08 | 2007-06-11 | 64, 59 | 24d | 0d | Trockenbaufirma | 16h |
| 66 | 1.8.2.4 | Ausführen Trockenausbau - Decke des 1. Geschosses | 2d | 2007-06-12 | 2007-06-13 | 65 | 24d | 0d | Trockenbaufirma | 16h |
| 67 | 1.8.2.5 | Spachteln und Grundieren des Trockenausbaus - Erdgeschoss | 1d | 2007-06-08 | 2007-06-08 | 64 | 0d |  | Trockenbaufirma | 8h |
| 68 | 1.8.2.6 | Spachteln und Grundieren des Trockenausbaus - 1. Geschoss | 1d | 2007-06-14 | 2007-06-14 | 66, 67 | 33d |  | Trockenbaufirma | 8h |
| 69 | 1.8.3 | **Tapete und Farbe** | 17d | 2007-06-11 | 2007-07-03 |  | 0d |  |  | 72h |
| 70 | 1.8.3.1 | Tapezieren aller Flächen außer Eingangsbereich und Küche - Erdgeschoss | 1d | 2007-06-11 | 2007-06-11 | 67 | 0d |  | Malerfirma | 8h |
| 71 | 1.8.3.2 | Streichen aller Flächen außer Eingangsbereich und Küche - Erdgeschoss | 1d | 2007-06-12 | 2007-06-12 | 70 | 0d |  | Malerfirma | 8h |
| 72 | 1.8.3.3 | Tapezieren des Eingangsbereichs und der Küche - Erdgeschoss | 1d | 2007-06-13 | 2007-06-13 | 71 | 0d |  | Malerfirma | 8h |
| 73 | 1.8.3.4 | Tapezieren aller Flächen - 1. Geschoss | 1d | 2007-06-12 | 2007-06-12 | 70 | 34d | 0d | Malerfirma | 8h |
| 74 | 1.8.3.5 | Streichen aller Flächen - 1. Geschoss | 1d | 2007-06-13 | 2007-06-13 | 73 | 34d |  | Malerfirma | 8h |
| 75 | 1.8.3.6 | Streichen der Fassade | 4d | 2007-06-28 | 2007-07-03 | 46 | 5d | 0d | Malerfirma | 32h |
| 76 | 1.8.4 | **Wandschränke** | 6d | 2007-06-14 | 2007-06-21 |  | 0d |  |  | 48h |
| 77 | 1.8.4.1 | Einbauen im Erdgeschoss - Küchenwandschränke | 2d | 2007-06-14 | 2007-06-15 | 72 | 0d |  | Schreinerfirma | 16h |
| 78 | 1.8.4.2 | Einbauen im Erdgeschoss - Wandschränke für Badezimmer und Gästebad | 1d | 2007-06-18 | 2007-06-18 | 77 | 0d |  | Schreinerfirma | 8h |
| 79 | 1.8.4.3 | Einbauen im 1. Geschoss - Wandschränke für weitere Badezimmer | 1d | 2007-06-19 | 2007-06-19 | 78 | 1d | 0d | Schreinerfirma | 8h |
| 80 | 1.8.4.4 | Einbauen der Küchentheke, Vertäfeln der Sitzecke | 2d | 2007-06-20 | 2007-06-21 | 79 | 20d |  | Schreinerfirma | 16h |

| ID | WBS | Task | Duration | Start | Finish | Predecessors | Total slack | Free slack | Resources | Work |
| --- | --- | --- | --- | --- | --- | --- | --- | --- | --- | --- |
| 81 | 1.8.5 | **Abschließen der Sanitärinstallation** | 6d | 2007-06-18 | 2007-06-25 |  | 0d |  |  | 48h |
| 82 | 1.8.5.1 | Vervollständigen im Erdgeschoss - Sanitärinstallation in der Küche | 1d | 2007-06-18 | 2007-06-18 | 77, 49 | 0d |  | Sanitärinstallationsfirma | 8h |
| 83 | 1.8.5.2 | Vervollständigen im Erdgeschoss - Sanitärinstallation im Badezimmer und Gästebad | 2d | 2007-06-19 | 2007-06-20 | 82, 78 | 0d |  | Sanitärinstallationsfirma | 16h |
| 84 | 1.8.5.3 | Vervollständigen im 1. Geschoss - Sanitärinstallation in weiteren Badezimmern | 2d | 2007-06-21 | 2007-06-22 | 83, 79 | 0d |  | Sanitärinstallationsfirma | 16h |
| 85 | 1.8.5.4 | Abnehmen der fertigen Sanitärinstallation | 1d | 2007-06-25 | 2007-06-25 | 84 | 0d |  | Bauordnungsamt | 8h |
| 86 | 1.8.6 | **Abschließen der Elektroinstallation** | 3d | 2007-06-25 | 2007-06-27 |  | 1d |  |  | 40h |
| 87 | 1.8.6.1 | Anschließen der Stromkreise des Erdgeschosses an den Sicherungskasten | 1d | 2007-06-25 | 2007-06-25 | 84, 52 | 3d | 0d | Elektroinstallationsfirma | 8h |
| 88 | 1.8.6.2 | Anschließen der Stromkreise des 1. Geschosses an den Sicherungskasten | 1d | 2007-06-26 | 2007-06-26 | 87 | 3d | 0d | Elektroinstallationsfirma | 8h |
| 89 | 1.8.6.3 | Abnehmen der fertigen Elektroinstallation | 1d | 2007-06-27 | 2007-06-27 | 88 | 3d |  | Bauordnungsamt | 8h |
| 90 | 1.8.6.4 | Vervollständigen der Kommunikationsanschlüsse - Telefon, Kabelanschluss, Computer, Alarmanlage | 2d | 2007-06-26 | 2007-06-27 | 85 | 0d |  | Elektroinstallationsfirma | 16h |
| 91 | 1.8.7 | **Abschließen der Klimaanlage** | 3d | 2007-06-28 | 2007-07-02 |  | 0d |  |  | 24h |
| 92 | 1.8.7.1 | Vervollständigen im Erdgeschoss - Kreis 1 der Klimaanlage | 1d | 2007-06-28 | 2007-06-28 | 90, 54 | 0d |  | Klimatechnikfirma | 8h |
| 93 | 1.8.7.2 | Vervollständigen im 1. Geschoss - Kreis 2 der Klimaanlage | 1d | 2007-06-29 | 2007-06-29 | 92 | 0d |  | Klimatechnikfirma | 8h |
| 94 | 1.8.7.3 | Abnehmen der Klimaanlage | 1d | 2007-07-02 | 2007-07-02 | 93 | 0d |  | Bauordnungsamt | 8h |
| 95 | 1.8.8 | **Teppichboden, Fliesen und Haushaltsgeräte** | 8d | 2007-07-03 | 2007-07-12 |  | 0d |  |  | 64h |
| 96 | 1.8.8.1 | Fliesen des Eingangsbereichs, der Küche und der Bäder | 3d | 2007-07-03 | 2007-07-05 | 89, 94 | 0d |  | Fußbodentechnikfirma | 24h |
| 97 | 1.8.8.2 | Verlegen des Teppichbodens im Erdgeschoss | 2d | 2007-07-06 | 2007-07-09 | 96 | 0d |  | Fußbodentechnikfirma | 16h |
| 98 | 1.8.8.3 | Verlegen des Teppichbodens im 1. Geschoss | 2d | 2007-07-10 | 2007-07-11 | 97 | 0d |  | Fußbodentechnikfirma | 16h |
| 99 | 1.8.8.4 | Einbauen der Haushaltsgeräte | 1d | 2007-07-12 | 2007-07-12 | 98 | 0d |  | Haushaltsgerätelieferant | 8h |
| 100 | 1.9 | **Garten- und Landschaftsbauarbeiten** | 12d | 2007-07-04 | 2007-07-19 |  | 0d |  |  | 56h |
| 101 | 1.9.1 | Pflastern der Einfahrt und des Bürgersteigs | 2d | 2007-07-04 | 2007-07-05 | 75 | 5d |  | Betonbaufirma | 16h |
| 102 | 1.9.2 | Aufstellen des Gartenzaunes | 2d | 2007-07-13 | 2007-07-16 | 99, 101 | 0d |  | Zaunbaufirma | 16h |
| 103 | 1.9.3 | Setzen der Pflanzen und Einsäen des Rasens - Vorgarten | 2d | 2007-07-17 | 2007-07-18 | 102 | 0d |  | Gartenbaufirma | 16h |
| 104 | 1.9.4 | Setzen der Pflanzen und Einsäen des Rasens - Hintergarten | 1d | 2007-07-19 | 2007-07-19 | 103 | 0d |  | Gartenbaufirma | 8h |

| ID | WBS | Task | Duration | Start | Finish | Predecessors | Total slack | Resources | Work |
| --- | --- | --- | --- | --- | --- | --- | --- | --- | --- |
| 105 | 1.10 | **Hausübergabe** | 8d | 2007-07-20 | 2007-07-31 |  | 0d |  | 64h |
| 106 | 1.10.1 | Durchführen der Endabnahme für die Einzugsgenehmigung | 1d | 2007-07-20 | 2007-07-20 | 104, 94, 89, 85, 61, 80, 50 | 0d | Bauordnungsamt | 8h |
| 107 | 1.10.2 | Säubern für den Einzug | 1d | 2007-07-23 | 2007-07-23 | 99, 106 | 0d | Reinigungsfirma | 8h |
| 108 | 1.10.3 | Begehen des Hauses zur Erstellung der Baumängelliste | 1d | 2007-07-24 | 2007-07-24 | 107 | 0d | Eigentümer | 8h |
| 109 | 1.10.4 | Beheben der Punkte der Mängelliste | 5d | 2007-07-25 | 2007-07-31 | 108 | 0d | Bauträger | 40h |
