# 4-Tapezieren - Ressourcenkonflikte beseitigt

Schedule from MS Project, 2013-12-05 to 2013-12-13, status date 2013-12-05.

## Calendars

- Standard: Mon-Fri 08:00-12:00, 13:00-17:00; Sat-Sun off.

## Resources

| Resource | Group | Unit | Rate |
| --- | --- | --- | --- |
| Farbe weiß |  | Liter | 2 |
| Peter | Maler |  |  |
| Mary | Maler |  |  |

## Schedule

| ID | WBS | Task | Type | Duration | Start | Finish | Predecessors | Total slack | Resources | Work |
| --- | --- | --- | --- | --- | --- | --- | --- | --- | --- | --- |
| 1 | 1 | **Renovierung** |  | 7d | 2013-12-05 | 2013-12-13 |  | 0d |  | 52h |
| 2 | 1.1 | Tapezieren |  | 2d | 2013-12-05 | 2013-12-06 |  | 0d | Peter | 16h |
| 3 | 1.2 | Trocknung |  | 2d | 2013-12-09 | 2013-12-10 | 2 | 0d |  |  |
| 4 | 1.3 | Abschluss Trocknung | milestone | 0d | 2013-12-10 | 2013-12-10 | 3 | 0d |  |  |
| 5 | 1.4 | **Malerarbeiten** |  | 3d | 2013-12-11 | 2013-12-13 | 4 | 0d |  | 36h |
| 6 | 1.4.1 | Flur |  | 2d | 2013-12-11 | 2013-12-12 |  | 1d | Mary [50%] | 8h |
| 7 | 1.4.2 | Wohnzimmer |  | 3d | 2013-12-11 | 2013-12-13 |  | 0d | Peter | 16h |
| 8 | 1.4.3 | Schlafzimmer |  | 2d | 2013-12-11 | 2013-12-12 |  | 1d | Mary [50%]; Peter [50%] | 12h |
